Schedule from MS Project, 2022-06-08 to 2022-08-31, status date 2022-06-14, costs in $, A marks actual dates.

## Calendars

- PROY: Mon-Sun 08:00-12:00, 13:00-17:00.

## Schedule

| ID | WBS | Task | Type | Duration | Start | Finish | Predecessors | Complete | Remaining | Baseline start | Baseline finish | Baseline duration | Total slack | Free slack | Cost | Baseline cost | Actual cost |
| --- | --- | --- | --- | --- | --- | --- | --- | --- | --- | --- | --- | --- | --- | --- | --- | --- | --- |
| 1 | 1 | **PRELIMINARES** |  | 20d | 2022-06-08 A | 2022-06-27 |  | 35% | 13.1d | 2022-06-08 | 2022-06-27 | 20d |  |  | 103,007,032.52 | 107,546,592 | 32,078,467 |
| 2 | 1.1 | **EXCAVACIÓN** |  | 20d | 2022-06-08 A | 2022-06-27 |  | 35% | 13.1d | 2022-06-08 | 2022-06-27 | 20d |  |  | 103,007,032.52 | 107,546,592 | 32,078,467 |
| 3 | 1.1.1 | MECÁNICA | manual | 20d | 2022-06-08 A | 2022-06-27 |  | 34% | 13.2d | 2022-06-08 | 2022-06-27 | 20d |  |  | 98,080,316.52 | 102,328,072 | 30,543,789 |
| 4 | 1.1.2 | MANUAL | manual | 20d | 2022-06-08 A | 2022-06-27 |  | 35% | 13d | 2022-06-08 | 2022-06-27 | 20d |  |  | 4,926,716 | 5,218,520 | 1,534,678 |
| 5 | 2 | **VÍAS** |  | 85d? | 2022-06-08 A | 2022-08-31 |  | 14% | 73.1d? | 2022-06-08 | 2022-07-17 | 40d |  |  | 1,576,987,808.1 | 1,582,647,368 | 75,678,905 |
| 6 | 2.1 | **MATERIAL** |  | 40d? | 2022-06-08 A | 2022-07-17 |  | 18% | 33d? | 2022-06-08 | 2022-07-17 | 40d |  |  | 1,576,987,808.1 | 1,582,647,368 | 75,678,905 |
| 7 | 2.1.1 | RAJÓN |  | 10d | 2022-06-08 A | 2022-06-17 |  | 70% | 3d | 2022-06-08 | 2022-06-17 | 10d | 40d | 0d | 110,538,247.1 | 116,197,807 | 75,678,905 |
| 8 | 2.1.2 | SUB-BASE |  | 10d | 2022-06-18 | 2022-06-27 | 7 |  |  | 2022-06-18 | 2022-06-27 | 10d | 40d | 0d | 245,065,423 | 245,065,423 |  |
| 9 | 2.1.3 | BASE |  | 10d | 2022-06-28 | 2022-07-07 | 8 |  |  | 2022-06-28 | 2022-07-07 | 10d | 40d | 0d | 324,765,478 | 324,765,478 |  |
| 10 | 2.1.4 | ASFALTO |  | 10d | 2022-07-08 | 2022-07-17 | 9 |  |  | 2022-07-08 | 2022-07-17 | 10d | 40d |  | 896,618,660 | 896,618,660 |  |
| 11 | 2.2 | **SEÑALIZACIÓN** |  | 5d | 2022-08-27 | 2022-08-31 | 6, 37 |  |  |  |  |  | 0d |  |  |  |  |
| 12 | 2.2.1 | VERTICAL |  | 5d | 2022-08-27 | 2022-08-31 | 42 |  |  |  |  |  | 0d |  |  |  |  |
| 13 | 2.2.2 | HORIZONTAL |  | 5d | 2022-08-27 | 2022-08-31 | 10 |  |  |  |  |  | 0d |  |  |  |  |
| 14 | 3 | **REDES** |  | 30d | 2022-06-28 | 2022-07-27 |  |  |  |  |  |  | 0d |  |  |  |  |
| 15 | 3.1 | **GAS** |  | 15d | 2022-06-28 | 2022-07-12 | 4 |  |  |  |  |  | 15d |  |  |  |  |
| 16 | 3.1.1 | TUB-RP 4 |  | 15d | 2022-06-28 | 2022-07-12 | 4 |  |  |  |  |  | 15d |  |  |  |  |
| 17 | 3.1.2 | TUB-RC 2 |  | 5d | 2022-06-28 | 2022-07-02 | 4 |  |  |  |  |  | 25d |  |  |  |  |
| 18 | 3.2 | **ACUEDUCTO** |  | 30d | 2022-06-28 | 2022-07-27 | 4 |  |  |  |  |  | 0d |  |  |  |  |
| 19 | 3.2.1 | TUB-RP 3 |  | 15d | 2022-06-28 | 2022-07-12 | 4 |  |  |  |  |  | 15d |  |  |  |  |
| 20 | 3.2.2 | TUB-RP 6 |  | 30d | 2022-06-28 | 2022-07-27 | 4 |  |  |  |  |  | 0d |  |  |  |  |
| 21 | 3.2.3 | TUB- RP 2 |  | 10d | 2022-06-28 | 2022-07-07 | 4 |  |  |  |  |  | 20d |  |  |  |  |
| 22 | 3.2.4 | TUB-RC |  | 10d | 2022-06-28 | 2022-07-07 | 4 |  |  |  |  |  | 20d |  |  |  |  |
| 23 | 3.2.5 | ACCESORIOS |  | 3d | 2022-06-28 | 2022-06-30 |  |  |  |  |  |  | 27d |  |  |  |  |
| 24 | 3.3 | **PLUVIAL** |  | 30d | 2022-06-28 | 2022-07-27 | 3 |  |  |  |  |  | 35d |  |  |  |  |
| 25 | 3.3.1 | TUB-RP |  | 30d | 2022-06-28 | 2022-07-27 | 3 |  |  |  |  |  | 35d |  |  |  |  |
| 26 | 3.3.2 | TUB-DOM |  | 15d | 2022-06-28 | 2022-07-12 | 3 |  |  |  |  |  | 50d |  |  |  |  |
| 27 | 3.3.3 | POZO |  | 20d | 2022-06-28 | 2022-07-17 | 3 |  |  |  |  |  | 45d |  |  |  |  |

| ID | WBS | Task | Duration | Start | Finish | Predecessors | Total slack |
| --- | --- | --- | --- | --- | --- | --- | --- |
| 28 | 3.4 | **SANITARIA** | 30d | 2022-06-28 | 2022-07-27 | 3 | 35d |
| 29 | 3.4.1 | TUB-RP | 30d | 2022-06-28 | 2022-07-27 | 3 | 35d |
| 30 | 3.4.2 | TUB-DOM | 15d | 2022-06-28 | 2022-07-12 | 3 | 50d |
| 31 | 3.4.3 | POZO | 20d | 2022-06-28 | 2022-07-17 | 3 | 45d |
| 32 | 3.5 | **ELÉCTRICA** | 25d | 2022-06-28 | 2022-07-22 | 4 | 5d |
| 33 | 3.5.1 | TUB-RP 3" | 15d | 2022-06-28 | 2022-07-12 | 4 | 15d |
| 34 | 3.5.2 | TUB-RP 6" | 25d | 2022-06-28 | 2022-07-22 | 4 | 5d |
| 35 | 3.5.3 | TUB-RC | 10d | 2022-06-28 | 2022-07-07 | 4 | 20d |
| 36 | 3.5.4 | CAJAS | 15d | 2022-06-28 | 2022-07-12 | 4 | 15d |
| 37 | 4 | **ANDENES** | 30d | 2022-07-28 | 2022-08-26 | 15, 18, 32 | 0d |
| 38 | 4.1 | **ESTRUCTURA** | 30d | 2022-07-28 | 2022-08-26 |  | 0d |
| 39 | 4.1.1 | RAJÓN | 10d | 2022-07-28 | 2022-08-06 |  | 0d |
| 40 | 4.1.2 | SELLO | 5d | 2022-08-07 | 2022-08-11 | 39 | 0d |
| 41 | 4.1.3 | NIVELACIÓN | 15d | 2022-08-12 | 2022-08-26 | 40 | 0d |
| 42 | 4.1.4 | ADOQUIN | 15d | 2022-07-28 | 2022-08-11 |  | 15d |
| 43 | 4.2 | **PREFABRICADOS** | 10d | 2022-08-07 | 2022-08-16 |  | 10d |
| 44 | 4.2.1 | SARDINEL | 10d | 2022-08-07 | 2022-08-16 | 39 | 10d |
| 45 | 4.2.2 | BORDILLO | 10d | 2022-08-07 | 2022-08-16 | 39 | 10d |
